# Question 6

Schedule from MS Project, 2006-09-18 to 2006-11-22.
Powered By Intel Centrino 1.5ghz

## Calendars

- Standard: Mon-Fri 08:00-12:00, 13:00-17:00; Sat-Sun off.

## Schedule

| ID | WBS | Task | Type | Duration | Start | Finish | Predecessors | Total slack | Free slack |
| --- | --- | --- | --- | --- | --- | --- | --- | --- | --- |
| 1 | 1 | A1 request for network connections |  | 1d | 2006-09-18 | 2006-09-18 |  | 20d | 0d |
| 2 | 2 | A2 request for system connection |  | 1d | 2006-09-18 | 2006-09-18 |  | 20d | 0d |
| 3 | 3 | A3 request multi-mode fiber connector |  | 1d | 2006-09-18 | 2006-09-18 |  | 20d | 0d |
| 4 | 4 | A4 ethernet and fast ethernet installed |  | 3d | 2006-09-19 | 2006-09-21 | 1, 2, 3 | 20d | 3d |
| 5 | 5 | A5 request PO for electrical connections |  | 2d | 2006-09-18 | 2006-09-19 |  | 17d | 0d |
| 6 | 6 | A6 install electrical connections |  | 5d | 2006-09-20 | 2006-09-26 | 5 | 17d | 0d |
| 7 | 7 | A7 request serial cable for console |  | 1d | 2006-09-18 | 2006-09-18 |  | 19d | 0d |
| 8 | 8 | A8 make serial cable |  | 4d | 2006-09-19 | 2006-09-22 | 7 | 19d | 2d |
| 9 | 9 | A9 schedule down time |  | 2d | 2006-09-18 | 2006-09-19 |  | 19d | 0d |
| 10 | 10 | A10 move MVS for supercomputer |  | 3d | 2006-09-20 | 2006-09-22 | 9 | 19d | 2d |
| 11 | 11 | A11 setup supercomputer |  | 5d | 2006-09-27 | 2006-10-03 | 4, 6, 8, 10 | 17d | 0d |
| 12 | 12 | A12 milestone | milestone | 0d | 2006-10-03 | 2006-10-03 | 11 | 17d |  |
| 15 | 13 | B1 verify hardware supported by Linux |  | 1d | 2006-09-18 | 2006-09-18 |  | 0d |  |
| 16 | 14 | B2 obtain console hardware |  | 4d | 2006-09-19 | 2006-09-22 | 15 | 0d |  |
| 17 | 15 | B3 obtain Linux |  | 1d | 2006-09-28 | 2006-09-28 | 18 | 1d |  |
| 18 | 16 | B4 plan Linux installation |  | 3d | 2006-09-25 | 2006-09-27 | 15, 16 | 0d |  |
| 19 | 17 | B5 determine subsystems to be installed |  | 2d | 2006-09-28 | 2006-09-29 | 18 | 0d |  |
| 20 | 18 | B6 install Linux |  | 3d | 2006-10-02 | 2006-10-04 | 17, 19 | 0d |  |
| 21 | 19 | B7 configure |  | 2d | 2006-10-05 | 2006-10-06 | 20 | 0d |  |
| 22 | 20 | B8 test |  | 5d | 2006-10-09 | 2006-10-13 | 21 | 7d |  |
| 23 | 21 | B9 obtain and install necessary software |  | 12d | 2006-10-09 | 2006-10-24 | 21 | 0d |  |
| 24 | 22 | B10 deploy |  | 2d | 2006-10-25 | 2006-10-26 | 22, 23 | 0d |  |
| 25 | 23 | B11 connect to supercomputer |  | 1d | 2006-10-27 | 2006-10-27 | 12, 24 | 0d |  |
| 26 | 24 | B12 milestone | milestone | 0d | 2006-10-27 | 2006-10-27 | 25 | 0d |  |
| 29 | 25 | C1 create supercomputer platform in Claim |  | 1d | 2006-10-30 | 2006-10-30 | 26 | 0d |  |
| 30 | 26 | C2 create three accounts and tie to supercomputer |  | 1d | 2006-10-31 | 2006-10-31 | 29 | 0d |  |
| 31 | 27 | C3 tie student account to CAF funding |  | 1d | 2006-11-01 | 2006-11-01 | 30 | 0d |  |
| 32 | 28 | C4 tie Claim server to supercomputer manager |  | 2d | 2006-11-02 | 2006-11-03 | 31 | 0d |  |
| 33 | 29 | C5 setup system accounting on supercomputer |  | 5d | 2006-11-06 | 2006-11-10 | 32 | 0d |  |
| 34 | 30 | C6 pre-load overhead account |  | 2d | 2006-11-13 | 2006-11-14 | 33 | 0d |  |
| 35 | 31 | C7 sub-allocate three Claim accounts |  | 2d | 2006-11-15 | 2006-11-16 | 34 | 0d |  |
| 36 | 32 | C8 merge supercomputer accounts into system |  | 4d | 2006-11-17 | 2006-11-22 | 35 | 0d |  |
| 37 | 33 | C9 milestone | milestone | 0d | 2006-11-22 | 2006-11-22 | 36 | 0d |  |
| 40 | 34 | D1 setup basic NQS on supercomputer |  | 4d | 2006-10-30 | 2006-11-02 | 26 | 8d | 0d |
| 41 | 35 | D2 configure MISER |  | 2d | 2006-11-03 | 2006-11-06 | 40 | 8d | 0d |
| 42 | 36 | D3 intergrate MISER in NQS |  | 2d | 2006-11-07 | 2006-11-08 | 41 | 8d | 0d |
| 43 | 37 | D4 configure checkpoint/restart |  | 2d | 2006-11-03 | 2006-11-06 | 40 | 10d | 2d |
| 44 | 38 | D5 intergrate checkpoint/restart in NQS |  | 2d | 2006-11-09 | 2006-11-10 | 42, 43 | 8d | 0d |
| 45 | 39 | D6 milestone | milestone | 0d | 2006-11-10 | 2006-11-10 | 44 | 8d |  |
| 48 | 40 | E1 determine disk layout |  | 5d | 2006-10-30 | 2006-11-03 | 26 | 12d | 0d |
| 49 | 41 | E2 create disk layout |  | 1d | 2006-11-06 | 2006-11-06 | 48 | 12d |  |
| 50 | 42 | E3 install backup software and configure |  | 3d | 2006-10-30 | 2006-11-01 | 26 | 15d |  |
| 51 | 43 | E4 install SSH |  | 1d | 2006-10-30 | 2006-10-30 | 26 | 1d | 0d |
| 52 | 44 | E5 install TCP_wrappers |  | 1d | 2006-10-31 | 2006-10-31 | 51 | 1d | 0d |
| 53 | 45 | E6 install Tripwire |  | 1d | 2006-11-01 | 2006-11-01 | 52 | 1d | 0d |
| 54 | 46 | E7 install Crack |  | 1d | 2006-11-02 | 2006-11-02 | 53 | 1d | 0d |
| 55 | 47 | E8 install Tiger |  | 1d | 2006-11-03 | 2006-11-03 | 54 | 1d | 0d |
| 56 | 48 | E9 SLM intergration |  | 5d | 2006-10-30 | 2006-11-03 | 26 | 13d |  |
| 57 | 49 | E10 install third-party software |  | 9d | 2006-09-18 | 2006-09-28 |  | 39d |  |
| 60 | 50 | F1 create policies |  | 16d | 2006-10-30 | 2006-11-20 | 26 | 2d |  |
| 61 | 51 | F2 announcement of new system |  | 1d | 2006-11-06 | 2006-11-06 | 55 | 12d |  |
| 62 | 52 | F3 update web pages |  | 3d | 2006-11-06 | 2006-11-08 | 55 | 10d |  |
| 63 | 53 | F4 review short courses |  | 3d | 2006-11-06 | 2006-11-08 | 55 | 10d |  |
| 64 | 54 | F5 review user guides |  | 12d | 2006-11-06 | 2006-11-21 | 55 | 1d |  |
